# 2011 Docking Plan

Schedule from MS Project, 2011-01-01 to 2012-07-05, A marks actual dates.
MBARI

## Calendars

- Standard: Mon-Fri 08:00-12:00, 13:00-17:00; Sat-Sun off.

## Resources

| Resource |
| --- |
| Brett |
| Thomas |
| Machine shop |
| Thomas Hoover |
| Test Tank |
| Zephyr |
| Jon Erickson |
| AUV Fabricator #1 |
| Yanwu Zhang |
| Rich |
| EE |
| SE |
| ME |
| MS |
| RE |
| ET |
| MT |
| Rob |
| Robert |
| Jim |
| Denis |
| Etech |
| Benthos |
| Brian |
| Waterat |
| Subconn |
| Rich Henthorn |

## Schedule

| ID | WBS | Task | Type | Duration | Start | Finish | Predecessors | Complete | Remaining | Total slack | Free slack | Constraint | Resources | Work | Actual work |
| --- | --- | --- | --- | --- | --- | --- | --- | --- | --- | --- | --- | --- | --- | --- | --- |
| 1 | 1 | Power Buoy AUV Docking | milestone | 0d | 2011-01-01 | 2011-01-01 |  |  |  | 325d |  |  |  |  |  |
| 2 | 2 | **Project planning** |  | 188d? | 2011-01-03 A | 2011-09-21 |  | 19% | 152.73d? | 205.27d |  |  |  | 304h | 100h |
| 3 | 2.1 | Brainstorming |  | 33.33d? | 2011-01-03 A | 2011-02-17 |  | 50% | 16.67d? | 0d |  |  | Jim [10%]; Brett [10%]; Rob [10%] | 80h | 40h |
| 4 | 2.2 | Model Dock Motion |  | 32.5d? | 2011-01-03 A | 2011-03-24 | 3 | 23% | 25d? | 0d |  |  | Rob | 80h | 60h |
| 5 | 2.3 | Model AUV Response |  | 50d? | 2011-03-24 | 2011-06-02 | 4 |  |  | 0d |  |  | Rob [10%] | 40h |  |
| 6 | 2.4 | **Plate measurements** |  | 177d? | 2011-01-18 | 2011-09-21 |  |  |  | 89d |  |  |  | 104h |  |
| 7 | 2.4.1 | design logger |  | 1d? | 2011-01-18 | 2011-01-18 |  |  |  | 328d | 0d | start no earlier than 2011-01-18 | Brett | 8h |  |
| 8 | 2.4.2 | order components |  | 1d? | 2011-01-19 | 2011-01-19 | 7 |  |  | 328d | 0d |  | Brett | 8h |  |
| 9 | 2.4.3 | assemble and bench test |  | 2d? | 2011-01-20 | 2011-01-21 | 8 |  |  | 328d | 0d |  | Brett | 16h |  |
| 10 | 2.4.4 | deployment |  | 2d? | 2011-01-24 | 2011-01-25 | 9 |  |  | 328d |  |  | Brett | 16h |  |
| 11 | 2.4.5 | Integrate ADV |  | 2d? | 2011-05-23 | 2011-05-24 |  |  |  | 0d |  | must start on 2011-05-23 | Robert | 16h |  |
| 12 | 2.4.6 | Collect ADV data | milestone | 0d | 2011-09-15 | 2011-09-15 | 11 |  |  | 157d | 0d | start no earlier than 2011-09-15 |  |  |  |
| 13 | 2.4.7 | Crunch IMU and ADV data |  | 5d? | 2011-09-15 | 2011-09-21 | 12 |  |  | 157d |  |  | Rob | 40h |  |
| 14 | 3 | **Homing system** |  | 183d? | 2011-01-03 A | 2011-09-14 |  | 38% | 114.12d? | 210.27d |  |  |  | 1000h | 176h |
| 15 | 3.1 | Survey options |  | 50d? | 2011-02-17 A | 2011-04-28 A | 3 | 100% |  |  |  |  | Brett [10%] | 40h | 40h |
| 16 | 3.2 | Choose system | milestone | 0d | 2011-04-28 | 2011-04-28 | 15 |  |  | 257.67d | 6.67d |  |  |  |  |
| 17 | 3.3 | Negotiate and order |  | 2d? | 2011-04-28 A | 2011-05-02 A | 16 | 100% |  |  |  |  | Brett | 16h | 16h |
| 18 | 3.4 | Build and ship |  | 6w | 2011-05-03 A | 2011-06-13 | 17 | 50% | 3w | 0d |  | must start on 2011-05-03 | Benthos | 240h | 120h |
| 19 | 3.5 | Bench and tank test |  | 14d | 2011-06-14 | 2011-07-01 | 18 |  |  | 5d | 0d |  | Brett | 112h |  |
| 20 | 3.6 | Return for calibration |  | 14d? | 2011-07-06 | 2011-07-25 | 56 |  |  | 247.27d |  |  | Benthos | 112h |  |
| 21 | 3.7 | Fast update software development |  | 60d | 2011-06-23 | 2011-09-14 |  |  |  | 0d |  | must finish on 2011-09-14 | Benthos | 480h |  |
| 22 | 3.8 | **Compass system** |  | 1d? | 2011-01-03 | 2011-01-03 |  |  |  | 392.27d |  |  |  |  |  |
| 23 | 3.8.1 | Choose and order compass |  | 1d? | 2011-01-03 | 2011-01-03 |  |  |  | 344d |  |  |  |  |  |
| 24 | 3.8.2 | Choose and order interface Microcomputer |  | 1d? | 2011-01-03 | 2011-01-03 |  |  |  | 344d |  |  |  |  |  |
| 25 | 3.8.3 | write interface code |  | 1d? | 2011-01-03 | 2011-01-03 |  |  |  | 344d |  |  |  |  |  |
| 26 | 3.8.4 | Tank Test |  | 1d? | 2011-01-03 | 2011-01-03 |  |  |  | 344d |  |  |  |  |  |
| 27 | 3.8.5 | Design subsea integration |  | 1d? | 2011-01-03 | 2011-01-03 |  |  |  | 344d |  |  |  |  |  |
| 28 | 3.8.6 | Modify transponder housing |  | 1d? | 2011-01-03 | 2011-01-03 |  |  |  | 344d |  |  |  |  |  |
| 29 | 3.8.7 | Insatll compass and MC |  | 1d? | 2011-01-03 | 2011-01-03 |  |  |  | 344d |  |  |  |  |  |
| 30 | 3.8.8 | Tank test |  | 1d? | 2011-01-03 | 2011-01-03 |  |  |  | 344d |  |  |  |  |  |

| ID | WBS | Task | Duration | Start | Finish | Predecessors | Complete | Remaining | Total slack | Free slack | Constraint | Deadline | Resources | Work | Actual work |
| --- | --- | --- | --- | --- | --- | --- | --- | --- | --- | --- | --- | --- | --- | --- | --- |
| 31 | 4 | **AUV** | 177.93d? | 2011-01-03 A | 2011-09-07 |  | 26% | 131.49d? | 215.33d |  |  |  |  | 896h | 340h |
| 32 | 4.1 | build long nose cone | 6w | 2011-05-03 A | 2011-06-13 |  | 33% | 4w | 16d | 3.5d |  |  | Waterat | 240h | 80h |
| 33 | 4.2 | Design integrate DAT PCBs | 4d? | 2011-05-09 A | 2011-05-12 | 16 | 50% | 2d? | 249d | 0d | start no earlier than 2011-05-08 |  | Robert | 32h | 16h |
| 34 | 4.3 | Design integrate DAT Transducer | 4d? | 2011-05-13 A | 2011-05-18 | 33 | 50% | 2d? | 247d |  |  |  | Robert | 32h | 16h |
| 35 | 4.4 | Order long nose-cone | 1d? | 2011-05-19 A | 2011-05-19 A | 34 | 100% |  |  |  |  |  | Brett | 8h | 8h |
| 36 | 4.5 | Design brackets | 1d? | 2011-05-20 A | 2011-05-20 | 35 | 50% | 0.5d? | 50d | 0d |  |  | Robert | 8h | 4h |
| 37 | 4.6 | Modify endbell for 12 conductor port | 1d? | 2011-05-23 A | 2011-05-23 A | 36 | 100% |  |  |  |  |  | Brett | 8h | 8h |
| 38 | 4.7 | Order 12 pin connector | 21d | 2011-05-03 A | 2011-05-31 A |  | 100% |  |  |  | start no earlier than 2011-05-03 |  | Subconn | 168h | 168h |
| 39 | 4.8 | Check compass effects | 1d? | 2011-05-24 A | 2011-05-24 A | 38 | 100% |  |  |  |  |  | Denis | 8h | 8h |
| 40 | 4.9 | Design wiring harness | 4d | 2011-05-25 A | 2011-05-30 A | 39 | 100% |  |  |  |  |  | Thomas | 32h | 32h |
| 41 | 4.10 | build wiring harness | 2w | 2011-05-31 | 2011-06-13 | 40 |  |  | 12.5d | 0d |  |  | Etech [10%] | 8h |  |
| 42 | 4.11 | Install 12 pin connector and wiring harness | 1d? | 2011-06-14 | 2011-06-14 | 41, 38 |  |  | 12.5d | 0d |  |  | Thomas | 8h |  |
| 43 | 4.12 | Final integration and test | 2.5d? | 2011-06-15 | 2011-06-17 | 42 |  |  | 12.5d | 0d |  |  | Brett; Thomas | 40h |  |
| 44 | 4.13 | **Software** | 177.93d? | 2011-01-03 | 2011-09-07 |  |  |  | 108.33d |  |  |  |  | 304h |  |
| 45 | 4.13.1 | Write DAT driver | 4d | 2011-07-04 | 2011-07-07 | 19 |  |  | 211d |  |  |  | Brian | 32h |  |
| 46 | 4.13.2 | Port old QNX Homing code | 28d | 2011-06-02 | 2011-07-12 | 5 |  |  | 0d |  |  |  | Rob [25%]; Rich Henthorn [25%] | 112h |  |
| 47 | 4.13.3 | Modify simulator for Homing | 24.33d? | 2011-07-12 | 2011-08-16 | 46 |  |  | 0d |  |  |  | Rob [25%]; Rich Henthorn [25%] | 56h |  |
| 48 | 4.13.4 | Run and refine code in simulator | 2d? | 2011-08-16 | 2011-08-18 | 47 |  |  | 0d |  |  |  | Rob [25%]; Rich Henthorn [25%] | 8h |  |
| 49 | 4.13.5 | Refine algorithm and simulator for DR nav and fast update rate | 14d? | 2011-08-18 | 2011-09-07 | 48 |  |  | 167.07d |  |  |  | Rob [25%]; Rich Henthorn [25%] | 56h |  |
| 50 | 4.13.6 | Debug and refine | 10d? | 2011-01-03 | 2011-01-14 |  |  |  | 335d |  |  |  | Rob [25%]; Rich Henthorn [25%] | 40h |  |
| 51 | 5 | **Dock** | 200d | 2011-05-23 | 2012-02-24 |  |  |  | 93.27d |  |  |  |  | 196h |  |
| 52 | 5.1 | Design cone dock based on existing design | 90d | 2011-05-23 | 2011-10-07 | 36 |  |  | 45d | 0d | start no earlier than 2011-05-15 |  | Brett [5%]; Robert [20%] | 96h |  |
| 53 | 5.2 | Design and build test dock | 100d | 2011-10-10 | 2012-02-24 | 52 |  |  | 45d |  |  |  | Brett [5%]; Robert [35%] | 100h |  |
| 54 | 6 | **Testing** | 273.77d? | 2011-06-17 | 2012-07-05 |  |  |  | 0d |  |  |  |  | 1120h |  |
| 55 | 6.1 | test prep | 6d | 2011-06-17 | 2011-06-27 | 43, 32 |  |  | 8.5d | 4.5d |  |  | Brett [50%]; Rob [50%]; Robert [50%] | 72h |  |
| 56 | 6.2 | DAT Validation - July 11 target | 2d? | 2011-07-04 | 2011-07-05 | 19, 55 |  |  | 4d | 0d |  | 2011-07-11 | Brett [50%]; Rob [50%]; Robert [50%] | 24h |  |
| 57 | 6.3 | test prep | 6d | 2011-07-06 | 2011-07-13 | 56 |  |  | 5.93d |  |  |  | Brett [50%]; Rob [50%]; Robert [50%] | 72h |  |
| 58 | 6.4 | Pure Pursuit Homing - Sept 1 target | 2d? | 2011-08-18 | 2011-08-22 | 57, 48 |  |  | 0d |  |  |  | Brett [50%]; Rob [50%]; Robert [50%] | 24h |  |
| 59 | 6.5 | test prep | 6d | 2011-10-03 | 2011-10-11 | 58FS+30d |  |  | 0d |  | start no earlier than 2011-08-21 |  | Brett [50%]; Rob [50%]; Robert [50%] | 72h |  |
| 60 | 6.6 | Directional Homing 1 - Oct 18 target | 2d? | 2011-10-11 | 2011-10-13 | 59, 21 |  |  | 0d |  | start no earlier than 2011-08-28 |  | Brett [50%]; Rob [50%]; Robert [50%] | 24h |  |
| 61 | 6.7 | test prep | 6d | 2011-10-13 | 2011-10-21 | 60 |  |  | 0d |  |  |  | Brett [50%]; Rob [50%]; Robert [50%] | 72h |  |
| 62 | 6.8 | Directional Homing 2 - November 7th target | 2d? | 2011-11-04 | 2011-11-08 | 61FS+10d |  |  | 0d |  |  |  | Brett [50%]; Rob [50%]; Robert [50%] | 24h |  |
| 63 | 6.9 | test prep | 6d? | 2011-11-08 | 2011-11-16 | 62 |  |  | 0d |  |  |  | Brett [50%]; Rob [50%]; Robert [50%] | 72h |  |
| 64 | 6.10 | Directional Homing 3 - November 21st target | 2d? | 2011-11-16 | 2011-11-18 | 63 |  |  | 0d |  |  |  | Brett [50%]; Rob [50%]; Robert [50%] | 24h |  |
| 65 | 6.11 | test prep | 3.33d? | 2012-02-10 | 2012-02-16 | 64FS+60d |  |  | 0d |  |  |  | Brett [50%]; Rob [50%]; Robert [50%] | 40h |  |
| 66 | 6.12 | Buoy Integration Test 1 - Mid February target | 2d? | 2012-02-16 | 2012-02-20 | 65 |  |  | 0d |  |  |  | Brett [50%]; Rob [50%]; Robert [50%] | 24h |  |
| 67 | 6.13 | test prep | 14d? | 2012-04-30 | 2012-05-18 | 66FS+50d |  |  | 0d |  |  |  | Brett [50%]; Rob [50%]; Robert [50%] | 168h |  |
| 68 | 6.14 | Docking Test 1- Mid May target | 2d? | 2012-05-18 | 2012-05-22 | 67 |  |  | 0d |  |  |  | Brett [50%]; Rob [50%]; Robert [50%] | 24h |  |
| 69 | 6.15 | test prep | 14d? | 2012-05-22 | 2012-06-11 | 68 |  |  | 0d |  |  |  | Brett [50%]; Rob [50%]; Robert [50%] | 168h |  |
| 70 | 6.16 | Docking Test 2 - June target | 2d? | 2012-06-11 | 2012-06-13 | 69 |  |  | 0d |  |  |  | Brett [50%]; Rob [50%]; Robert [50%] | 24h |  |
| 71 | 6.17 | test prep | 14d? | 2012-06-13 | 2012-07-03 | 70 |  |  | 0d |  |  |  | Brett [50%]; Rob [50%]; Robert [50%] | 168h |  |
| 72 | 6.18 | Final Docking Demo - July target | 2d? | 2012-07-03 | 2012-07-05 | 71 |  |  | 0d |  |  |  | Brett [50%]; Rob [50%]; Robert [50%] | 24h |  |

| ID | WBS | Task | Duration | Start | Finish | Total slack | Resources | Work |
| --- | --- | --- | --- | --- | --- | --- | --- | --- |
| 74 | 7 | **Misc.** | 345d? | 2011-01-03 | 2012-04-27 | 48.27d |  | 92h |
| 75 | 7.1 | **Meetings, Presentations, Documentation** | 345d? | 2011-01-03 | 2012-04-27 | 48.27d |  | 92h |
| 76 | 7.1.1 | Weekley meetings | 335d? | 2011-01-03 | 2012-04-27 | 48.27d | Brett [1%]; Rob [1%] | 52h |
| 77 | 7.1.2 | presentations | 2d? | 2011-01-03 | 2011-01-04 | 343d | Brett | 16h |
| 78 | 7.1.3 | work up project plan | 3d? | 2011-01-03 | 2011-01-05 | 342d | Brett | 24h |
