# Phase 2

Schedule from MS Project, 2010-05-27 to 2010-10-26.
MBARI

## Calendars

- Standard: Mon-Fri 08:00-12:00, 13:00-17:00; Sat-Sun off.

## Schedule

| ID | WBS | Task | Duration | Start | Finish | Predecessors | Total slack | Free slack | Constraint |
| --- | --- | --- | --- | --- | --- | --- | --- | --- | --- |
| 3 | 1 | Submerged Plate Design | 23d | 2010-06-30 | 2010-07-30 |  | 2d | 0d | start no earlier than 2010-06-30 |
| 4 | 2 | Submerged Plate Fabrication | 35d | 2010-08-02 | 2010-09-17 | 3 | 2d |  |  |
| 6 | 3 | Buoy Design | 14d | 2010-06-30 | 2010-07-19 |  | 2d | 0d | start no earlier than 2010-06-30 |
| 7 | 4 | Buoy Fabrication | 44d | 2010-07-20 | 2010-09-17 | 6 | 2d |  |  |
| 9 | 5 | Test Machine Design | 17d | 2010-05-27 | 2010-06-18 |  | 2d | 0d | start no earlier than 2010-05-27 |
| 10 | 6 | Test Machine Fabrication and Integration | 29d | 2010-06-21 | 2010-07-29 | 9 | 2d |  | start no earlier than 2010-06-17 |
| 14 | 7 | Controller Electronics Enclosure Design/Spec | 12d | 2010-06-21 | 2010-07-06 |  | 10d | 0d | start no earlier than 2010-06-21 |
| 15 | 8 | Controller Enclosure Fabrication/Assembly | 13d | 2010-07-07 | 2010-07-23 | 14 | 10d | 0d |  |
| 16 | 9 | Controller Software Development | 30d | 2010-07-26 | 2010-09-03 | 15 | 10d |  |  |
| 18 | 10 | Overall Electrical System Documentation | 14d | 2010-05-27 | 2010-06-15 |  | 10d | 3d | start no earlier than 2010-05-27 |
| 19 | 11 | Connector/Penetrator specifications | 14d | 2010-05-27 | 2010-06-15 |  | 10d | 3d | start no earlier than 2010-05-27 |
| 20 | 12 | Electrical System Design Review | 1d? | 2010-06-21 | 2010-06-21 | 18, 19 | 7d | 0d | start no earlier than 2010-06-21 |
| 22 | 13 | Power Electronics Enclosure Designs | 14d | 2010-06-22 | 2010-07-09 | 20 | 7d | 0d | start no earlier than 2010-05-27 |
| 23 | 14 | P.E. Enclosure Fabrication/Assembly | 14d | 2010-07-12 | 2010-07-29 | 22 | 7d | 0d | start no earlier than 2010-05-27 |
| 25 | 15 | Battery/Load-Dump System Design | 16d | 2010-05-28 | 2010-06-18 |  | 8d | 0d | start no earlier than 2010-05-28 |
| 26 | 16 | Battery/Load-Dump Design Review | 1d? | 2010-06-21 | 2010-06-21 | 25 | 8d | 0d |  |
| 27 | 17 | Battery/Load-Dump System Fabrication | 28d | 2010-06-22 | 2010-07-29 | 26 | 8d |  |  |
| 29 | 18 | FailSafe Switch/Relay Specification and Order | 16d | 2010-05-27 | 2010-06-17 |  | 91d |  | start no earlier than 2010-05-27 |
| 30 | 19 | Specify and order Load Cell | 16d | 2010-05-27 | 2010-06-17 |  | 1d |  | start no earlier than 2010-05-27 |
| 31 | 20 | Specify and Order Temperature Sensors | 16d | 2010-05-27 | 2010-06-17 |  | 1d |  | start no earlier than 2010-05-27 |
| 32 | 21 | Specify and Order Pressure Sensors | 16d | 2010-05-27 | 2010-06-17 |  | 1d |  | start no earlier than 2010-05-27 |
| 33 | 22 | Specify and Order Coil Cord | 16d | 2010-05-27 | 2010-06-17 |  | 1d |  | start no earlier than 2010-05-27 |
| 35 | 23 | PTO Electronics Board Design | 9d | 2010-05-28 | 2010-06-09 |  | 0d |  | start no earlier than 2010-05-28 |
| 36 | 24 | PTO Electronics Board Design Review | 1d? | 2010-06-10 | 2010-06-10 | 35 | 0d |  |  |
| 37 | 25 | PTO Electronics Board Layout | 9d | 2010-06-11 | 2010-06-23 | 36 | 0d |  | start no earlier than 2010-06-01 |
| 38 | 26 | PTO Electronics Board Fabrication | 7d | 2010-06-24 | 2010-07-02 | 37 | 0d |  |  |
| 39 | 27 | PTO Electronics Software Development | 21d | 2010-07-05 | 2010-08-02 | 38 | 0d |  | finish no earlier than 2010-07-09 |
| 41 | 28 | Pneumatic Spring Mechanical Design Review | 1d? | 2010-06-21 | 2010-06-21 | 30, 31, 32, 33 | 2d | 0d | start no earlier than 2010-06-21 |
| 42 | 29 | Pnuematic Spring Component Fabrication | 28d | 2010-06-22 | 2010-07-29 | 41 | 2d |  |  |
| 43 | 30 | Pnuematic Spring Assembly and Test | 8d | 2010-08-03 | 2010-08-12 | 42, 39, 10 | 0d |  | start no earlier than 2010-07-12 |
| 44 | 31 | Levant Delivery | 1d? | 2010-07-30 | 2010-07-30 | 23 | 9d |  | start no earlier than 2010-07-30 |
| 45 | 32 | OceanGen - Pneumatic Spring Integration | 8d | 2010-08-13 | 2010-08-24 | 44, 43, 27 | 0d |  |  |
| 46 | 33 | In Lab Testing | 20d | 2010-08-25 | 2010-09-21 | 45, 15 | 0d |  | start no earlier than 2010-08-09 |
| 47 | 34 | Buoy/PTO Integration | 20d | 2010-09-22 | 2010-10-19 | 46, 4, 7, 16 | 0d |  |  |
| 48 | 35 | At-Sea Testing | 5d | 2010-10-20 | 2010-10-26 | 47 | 0d |  |  |
